Schedule from MS Project, 2007-06-26 to 2009-09-20.

## Calendars

- 标准: Mon-Fri 08:00-12:00, 13:00-17:00; Sat-Sun off. Exceptions (off unless hours are given): 2004-04-01 to 2009-12-31 08:00-12:00, 13:00-17:00.

## Schedule

| ID | WBS | Task | Duration | Start | Finish | Predecessors | Total slack | Free slack | Constraint |
| --- | --- | --- | --- | --- | --- | --- | --- | --- | --- |
| 1 | 1 | **总进度计划** | 818d | 2007-06-26 | 2009-09-20 |  | 0d |  |  |
| 2 | 1.1 | 施工准备 | 5d | 2007-06-26 | 2007-06-30 |  | 0d |  | start no earlier than 2007-06-26 |
| 3 | 1.2 | **地下室工程施工** | 209d | 2007-07-01 | 2008-01-25 |  | 0d |  |  |
| 4 | 1.2.1 | 中区、南区垫层及防水 | 12d | 2007-07-01 | 2007-07-12 | 2 | 0d |  |  |
| 5 | 1.2.2 | 中区、南区底板结构 | 30d | 2007-07-13 | 2007-08-11 | 4 | 0d |  |  |
| 6 | 1.2.3 | 北区、东区垫层及防水 | 15d | 2007-07-01 | 2007-07-15 | 2 | 773d | 0d |  |
| 7 | 1.2.4 | 北区、东区底板结构 | 30d | 2007-07-16 | 2007-08-14 | 6 | 768d |  |  |
| 8 | 1.2.5 | 地下四层结构 | 38d | 2007-08-12 | 2007-09-18 | 5 | 0d |  |  |
| 9 | 1.2.6 | 地下三层结构 | 38d | 2007-09-04 | 2007-10-11 | 8FS-15d | 0d |  |  |
| 10 | 1.2.7 | 地下二层结构 | 38d | 2007-09-27 | 2007-11-03 | 9FS-15d | 0d |  |  |
| 11 | 1.2.8 | 地下一层结构 | 38d | 2007-10-20 | 2007-11-26 | 10FS-15d | 0d |  |  |
| 12 | 1.2.9 | 地下室外墙防水施工 | 30d | 2007-11-27 | 2007-12-26 | 11 | 604d | 0d |  |
| 13 | 1.2.10 | 地下室土方回填 | 30d | 2007-12-27 | 2008-01-25 | 12 | 604d |  |  |
| 14 | 1.3 | **裙房结构施工** | 58d | 2007-11-17 | 2008-01-13 |  | 0d |  |  |
| 15 | 1.3.1 | 首层结构 | 26d | 2007-11-17 | 2007-12-12 | 11FS-10d | 0d |  |  |
| 16 | 1.3.2 | 二层结构 | 26d | 2007-12-03 | 2007-12-28 | 15FS-10d | 0d |  |  |
| 17 | 1.3.3 | 三层结构 | 26d | 2007-12-19 | 2008-01-13 | 16FS-10d | 0d |  |  |
| 18 | 1.4 | **南楼上部结构** | 145d | 2008-01-04 | 2008-05-27 |  | 351d |  |  |
| 19 | 1.4.1 | 南楼四~十三层结构 | 70d | 2008-01-04 | 2008-03-13 | 17FS-10d | 351d | 0d |  |
| 20 | 1.4.2 | 南楼十四~二十三层屋顶结构 | 75d | 2008-03-14 | 2008-05-27 | 19 | 351d | 0d |  |
| 21 | 1.5 | **中楼上部结构** | 175d | 2008-01-04 | 2008-06-26 |  | 0d |  |  |
| 22 | 1.5.1 | 中楼四~十四层结构 | 55d | 2008-01-04 | 2008-02-27 | 17FS-10d | 0d |  |  |
| 23 | 1.5.2 | 中楼十五~二十五结构 | 55d | 2008-02-28 | 2008-04-22 | 22 | 251d | 0d |  |
| 24 | 1.5.3 | 中楼二十六~三十六层结构 | 55d | 2008-04-23 | 2008-06-16 | 23 | 251d | 0d |  |
| 25 | 1.5.4 | 中楼三十七、屋顶层结构 | 10d | 2008-06-17 | 2008-06-26 | 24 | 251d | 0d |  |

| ID | WBS | Task | Duration | Start | Finish | Predecessors | Total slack | Free slack | Constraint |
| --- | --- | --- | --- | --- | --- | --- | --- | --- | --- |
| 26 | 1.6 | **北楼上部结构** | 75d | 2008-01-14 | 2008-03-28 |  | 456d |  |  |
| 27 | 1.6.1 | 北楼四~八层结构 | 50d | 2008-01-14 | 2008-03-03 | 17 | 456d | 0d |  |
| 28 | 1.6.2 | 北楼九层~屋顶结构 | 25d | 2008-03-04 | 2008-03-28 | 27 | 456d | 0d |  |
| 29 | 1.7 | 地下砌筑工程 | 70d | 2007-12-12 | 2008-02-19 | 11FS+15d | 144d | 0d |  |
| 30 | 1.8 | 地上砌筑工程 | 150d | 2008-02-28 | 2008-07-26 | 22 | 0d |  |  |
| 31 | 1.9 | 北楼屋面工程 | 30d | 2008-03-29 | 2008-04-27 | 28 | 511d |  |  |
| 32 | 1.10 | 中楼、南楼屋面工程 | 45d | 2008-06-27 | 2008-08-10 | 25 | 356d | 95d | start no earlier than 2007-03-15 |
| 33 | 1.11 | 裙房屋面工程 | 50d | 2008-11-14 | 2009-01-02 | 32, 46 | 261d |  | start no earlier than 2008-03-10 |
| 34 | 1.12 | **装饰工程施工** | 511d | 2008-03-29 | 2009-08-21 |  | 30d |  |  |
| 35 | 1.12.1 | 北楼外墙保温 | 25d | 2008-03-29 | 2008-04-22 | 28 | 456d | 0d |  |
| 36 | 1.12.2 | 北楼外墙玻璃幕墙 | 60d | 2008-03-29 | 2008-05-27 | 28 | 481d |  |  |
| 37 | 1.12.3 | 北楼外墙干挂磨光花岗岩 | 30d | 2008-04-23 | 2008-05-22 | 35 | 456d | 0d |  |
| 38 | 1.12.4 | 北楼外墙铝板饰面 | 30d | 2008-05-23 | 2008-06-21 | 37 | 456d |  |  |
| 39 | 1.12.5 | 中楼21层以下外墙保温 | 50d | 2008-04-23 | 2008-06-11 | 23 | 376d | 0d |  |
| 40 | 1.12.6 | 中楼21层以下外墙玻璃幕墙 | 100d | 2008-04-23 | 2008-07-31 | 23 | 416d |  |  |
| 41 | 1.12.7 | 中楼21层以下干外墙挂磨光花岗岩 | 50d | 2008-06-12 | 2008-07-31 | 39 | 376d | 0d |  |
| 42 | 1.12.8 | 中楼21层以下外墙铝板饰面 | 40d | 2008-08-01 | 2008-09-09 | 41 | 376d |  |  |
| 43 | 1.12.9 | 中楼21层以上外墙保温 | 50d | 2008-06-27 | 2008-08-15 | 25 | 251d | 0d |  |
| 44 | 1.12.10 | 中楼21层以上外墙玻璃幕墙 | 90d | 2008-06-27 | 2008-09-24 | 25 | 361d |  |  |
| 45 | 1.12.11 | 中楼21层以上外墙干挂磨光花岗岩 | 50d | 2008-08-16 | 2008-10-04 | 43 | 251d | 0d |  |
| 46 | 1.12.12 | 中楼21层以上外墙铝板饰面 | 40d | 2008-10-05 | 2008-11-13 | 45 | 251d | 0d |  |
| 47 | 1.12.13 | 南楼外墙保温 | 40d | 2008-05-28 | 2008-07-06 | 20 | 351d | 0d |  |
| 48 | 1.12.14 | 南楼外墙玻璃幕墙 | 100d | 2008-05-28 | 2008-09-04 | 20 | 381d |  | start no earlier than 2007-03-15 |
| 49 | 1.12.15 | 南楼外墙干挂磨光花岗岩 | 40d | 2008-07-07 | 2008-08-15 | 47 | 351d | 0d |  |
| 50 | 1.12.16 | 南楼外墙铝板饰面 | 50d | 2008-08-16 | 2008-10-04 | 49 | 351d |  |  |
| 51 | 1.12.17 | 室内抹灰及楼面防水基层 | 70d | 2008-06-07 | 2008-08-15 | 30FS-50d | 351d | 0d |  |
| 52 | 1.12.18 | 楼面防水 | 50d | 2008-08-16 | 2008-10-04 | 51 | 351d |  |  |
| 53 | 1.12.19 | 室内涂料类顶棚装饰 | 70d | 2008-06-07 | 2008-08-15 | 30FS-50d | 0d |  |  |
| 54 | 1.12.20 | 室内吊顶类顶棚装饰 | 100d | 2008-08-16 | 2008-11-23 | 53 | 241d | 0d |  |
| 55 | 1.12.21 | 室内涂料墙面装饰 | 100d | 2008-08-16 | 2008-11-23 | 53 | 0d |  |  |
| 56 | 1.12.22 | 室内块料及专业墙面装饰 | 110d | 2008-11-24 | 2009-03-13 | 55 | 0d |  |  |
| 57 | 1.12.23 | 室内楼地面工程 | 120d | 2009-01-24 | 2009-05-23 | 56FS-49d | 0d |  |  |
| 58 | 1.12.24 | 门窗工程 | 160d | 2008-07-27 | 2009-01-02 | 30 | 261d |  |  |
| 59 | 1.12.25 | 二次精装修 | 90d | 2009-05-24 | 2009-08-21 | 57 | 0d |  |  |

| ID | WBS | Task | Duration | Start | Finish | Predecessors | Total slack | Free slack | Constraint |
| --- | --- | --- | --- | --- | --- | --- | --- | --- | --- |
| 60 | 1.13 | **机电安装工程** | 677d | 2007-07-13 | 2009-05-19 |  | 124d |  |  |
| 61 | 1.13.1 | 机电预留预埋工程 | 312d | 2007-07-13 | 2008-05-19 | 5SS | 314d | 0d |  |
| 62 | 1.13.2 | 电梯安装 | 100d | 2008-06-19 | 2008-09-26 | 61FS+30d | 314d | 0d |  |
| 63 | 1.13.3 | 电梯调试 | 45d | 2008-09-27 | 2008-11-10 | 62 | 314d |  |  |
| 64 | 1.13.4 | 给排水工程管道安装 | 250d | 2007-12-12 | 2008-08-17 | 29SS | 144d | 0d |  |
| 65 | 1.13.5 | 给排水设备安装 | 100d | 2008-07-04 | 2008-10-11 | 64FS-45d | 124d | 0d |  |
| 66 | 1.13.6 | 卫生洁具、喷头、消火栓箱安装 | 160d | 2008-10-12 | 2009-03-20 | 65 | 124d | 0d |  |
| 67 | 1.13.7 | 电缆桥架及线槽安装 | 250d | 2007-12-12 | 2008-08-17 | 29SS | 249d | 0d |  |
| 68 | 1.13.8 | 配电箱及支配线架安装 | 110d | 2008-08-18 | 2008-12-05 | 67 | 289d |  |  |
| 69 | 1.13.9 | 电气配管配线及电缆敷设 | 370d | 2008-01-11 | 2009-01-14 | 67SS+30d | 249d |  |  |
| 70 | 1.13.10 | 灯具、开关面板及弱电末端安装 | 160d | 2008-08-16 | 2009-01-22 | 54SS | 241d |  |  |
| 71 | 1.13.11 | 风管制作、安装 | 230d | 2007-12-12 | 2008-07-28 | 67SS | 299d | 0d |  |
| 72 | 1.13.12 | 空调管道及设备安装 | 250d | 2008-01-11 | 2008-09-16 | 71SS+30d | 299d | 0d |  |
| 73 | 1.13.13 | 风口安装 | 100d | 2008-08-28 | 2008-12-05 | 72FS-20d | 289d |  | start no earlier than 2005-12-18 |
| 74 | 1.13.14 | 系统调试及联合调试 | 60d | 2009-03-21 | 2009-05-19 | 66 | 124d |  |  |
| 75 | 1.14 | 室外总平面施工 | 60d | 2009-02-22 | 2009-04-22 | 46FS+100d | 151d |  | start no earlier than 2007-03-15 |
| 76 | 1.15 | 清理及竣工验收 | 30d | 2009-08-22 | 2009-09-20 | 59 | 0d |  |  |
